# mirom2

Schedule from MS Project, 2011-03-28 to 2011-05-09, costs in €.

## Calendars

- Standardní: Mon-Fri 08:00-12:00, 13:00-17:00; Sat-Sun off.

## Resources

| Resource | Unit |
| --- | --- |
| Pracovnici |  |
| tehla | ks |
| voda | m3 |
| malta | m3 |
| betón C20/25 | m3 |

## Schedule

| ID | WBS | Task | Duration | Start | Finish | Predecessors | Total slack | Resources | Work | Cost | Text2 | Text3 | Text5 | Text6 | Text7 | Text8 | Text9 | Text12 | Text13 |
| --- | --- | --- | --- | --- | --- | --- | --- | --- | --- | --- | --- | --- | --- | --- | --- | --- | --- | --- | --- |
| 1 | 1 | **SO 320** | 31d | 2011-03-28 | 2011-05-09 |  | 0d |  | 1064h | 200,145.8 |  |  |  |  |  |  |  |  |  |
| 2 | 1.1 | Výkop | 11d | 2011-03-28 | 2011-04-11 |  | 0d | Pracovnici [200%] | 176h | 150,000 | m3 |  |  |  |  |  |  |  |  |
| 3 | 1.2 | Betonáž podklad. betónu | 1d | 2011-04-12 | 2011-04-12 | 2 | 0d | Pracovnici [500%] | 40h | 1,452 | m3 | 892 | 4460 | 36 | 32112 | 23 | 14 | 141,3 | 146,25 |
| 4 | 1.3 | Armovanie pätiek | 2d | 2011-04-13 | 2011-04-14 | 3 | 0d | Pracovnici [500%] | 80h | 4,005 |  |  |  |  |  |  |  |  |  |
| 5 | 1.4 | Zadebnenie pätiek | 2d | 2011-04-15 | 2011-04-18 | 4 | 0d | Pracovnici [600%] | 96h | 1,980 | m2 |  |  |  |  |  |  |  |  |
| 6 | 1.5 | Betonáž pätky | 1d | 2011-04-19 | 2011-04-19 | 5 | 0d | Pracovnici [600%] | 48h | 13,068 | m3 |  |  |  |  |  |  |  |  |
| 7 | 1.6 | Oddebnenie pätky | 1d | 2011-04-20 | 2011-04-20 | 6 | 0d | Pracovnici [600%] | 48h | 356.4 | m2 |  |  |  |  |  |  |  |  |
| 8 | 1.7 | Obsyp pätiek so zhutnením | 1d | 2011-04-21 | 2011-04-21 | 7 | 0d | Pracovnici [300%] | 24h | 17,416 | m3 |  |  |  |  |  |  |  |  |
| 9 | 1.8 | Izolovanie pod stlpom | 1d | 2011-04-22 | 2011-04-22 | 8 | 0d | Pracovnici [600%] | 48h | 24 | m2 |  |  |  |  |  |  |  |  |
| 10 | 1.9 | Armovanie stĺpov | 1d | 2011-04-25 | 2011-04-25 | 9 | 0d | Pracovnici [300%] | 24h | 834.4 |  |  |  |  |  |  |  |  |  |
| 11 | 1.10 | Debnenie stĺpov | 2d | 2011-04-26 | 2011-04-27 | 10 | 0d | Pracovnici [600%] | 96h | 2,400 | m2 |  |  |  |  |  |  |  |  |
| 12 | 1.11 | Betonáž stĺpov | 1d | 2011-04-28 | 2011-04-28 | 11 | 0d | Pracovnici [600%] | 48h | 1,920 | m3 |  |  |  |  |  |  |  |  |
| 13 | 1.12 | Oddebnenie stĺpov | 1d | 2011-04-29 | 2011-04-29 | 12 | 0d | Pracovnici [600%] | 48h | 240 | m2 |  |  |  |  |  |  |  |  |
| 14 | 1.13 | Debnenie stropu a prievlakov 1.n.p. | 3d | 2011-05-02 | 2011-05-04 | 13 | 0d | Pracovnici [600%] | 144h | 1,950 | m2 |  |  |  |  |  |  |  |  |
| 15 | 1.14 | Armovanie stropu 1.n.p. | 1d | 2011-05-05 | 2011-05-05 | 14 | 0d | Pracovnici [600%] | 48h |  |  |  |  |  |  |  |  |  |  |
| 16 | 1.15 | Betonáž stropu 1.n.p. | 1d | 2011-05-06 | 2011-05-06 | 15 | 0d | Pracovnici [600%] | 48h | 3,900 | m3 |  |  |  |  |  |  |  |  |
| 17 | 1.16 | Oddebnenie stropu 1.n.p. | 1d | 2011-05-09 | 2011-05-09 | 16 | 0d | Pracovnici [600%] | 48h | 600 | m2 |  |  |  |  |  |  |  |  |
